Schedule from MS Project, 2006-10-02 to 2006-12-01.
_

## Calendars

- Estándar: Mon-Tue 12:00-14:00, 18:20-20:20; Wed 12:00-14:00, 16:30-18:15; Thu 12:00-14:00; Fri 12:00-14:00, 16:30-18:15; Sat-Sun off. Exceptions (off unless hours are given): 2006-10-12 to 2006-10-13, 2006-10-25, 2006-11-01.
- Calendario de clase (trabajo): Mon-Tue 18:20-20:20; Wed 16:30-18:15; Thu off; Fri 16:30-18:15; Sat-Sun off. Exceptions (off unless hours are given): 2006-10-02 to 2006-10-06, 2006-10-09, 2006-10-10 19:30-20:20, 2006-10-11 to 2006-10-13, 2006-10-16 to 2006-10-17 19:30-20:20, 2006-10-18, 2006-10-20, 2006-10-23 to 2006-10-24 19:30-20:20, 2006-10-25, 2006-10-27 17:20-18:15, 2006-10-30 to 2006-10-31 19:30-20:20, 2006-11-01, 2006-11-03 17:20-18:15.

## Resources

| Resource |
| --- |
| profesor |
| técnico DPE |

## Schedule

| ID | WBS | Task | Duration | Start | Finish | Predecessors | Baseline start | Baseline finish | Baseline duration | Total slack | Free slack | Calendar | Resources | Work |
| --- | --- | --- | --- | --- | --- | --- | --- | --- | --- | --- | --- | --- | --- | --- |
| 1 | 1 | presentación | 1h | 2006-10-02 | 2006-10-02 |  | 2006-10-02 | 2006-10-02 | 1h | 0.56d | 0d |  | profesor | 1h |
| 2 | 2 | **estudios previos** | 6.45d | 2006-10-02 | 2006-10-24 | 1 | 2006-10-02 | 2006-10-24 | 6.45d | 0.56d |  |  |  | 21h |
| 3 | 2.1 | estudio del PIC16F84 | 8h | 2006-10-02 | 2006-10-09 |  | 2006-10-02 | 2006-10-09 | 8h | 0.56d | 0d |  | profesor | 8h |
| 4 | 2.2 | práctica PIC16F84 | 4h | 2006-10-10 | 2006-10-24 | 3 | 2006-10-10 | 2006-10-24 | 4h | 0.14d | 0d | Calendario de clase (trabajo) | técnico DPE | 4h |
| 5 | 2.3 | estudio del PIC16F88 | 4h | 2006-10-09 | 2006-10-17 | 3 | 2006-10-09 | 2006-10-17 | 4h | 0.71d | 0d |  | profesor | 4h |
| 6 | 2.4 | estudio de MS-Project | 3h | 2006-10-18 | 2006-10-23 | 7 | 2006-10-18 | 2006-10-23 | 3h | 2.32d |  |  | profesor | 3h |
| 7 | 2.5 | estudio de la conversión A/D | 2h | 2006-10-17 | 2006-10-18 | 5 | 2006-10-17 | 2006-10-18 | 2h | 1.68d | 0d |  | profesor | 2h |
| 8 | 3 | **realización del hardware** | 11.27d | 2006-10-17 | 2006-11-24 | 5 | 2006-10-17 | 2006-11-24 | 11.27d | 0d |  |  |  | 38h |
| 9 | 3.1 | **realización del prototipo en wrapping** | 8.47d | 2006-10-17 | 2006-11-15 |  | 2006-10-17 | 2006-11-15 | 8.47d | 0.05d | 0d |  |  | 26h |
| 10 | 3.1.1 | diseño del sistema | 8h | 2006-10-17 | 2006-10-20 |  | 2006-10-17 | 2006-10-20 | 8h | 0.88d | 0.82d |  | técnico DPE | 8h |
| 11 | 3.1.2 | montaje | 2h | 2006-10-23 | 2006-10-27 | 10 | 2006-10-23 | 2006-10-27 | 2h | 0.05d | 0d | Calendario de clase (trabajo) | técnico DPE | 2h |
| 12 | 3.1.3 | pruebas del circuito básico | 2h | 2006-10-27 | 2006-10-31 | 11 | 2006-10-27 | 2006-10-31 | 2h | 0.05d | 0d | Calendario de clase (trabajo) | técnico DPE | 2h |
| 13 | 3.1.4 | pruebas de pulsadores | 3h | 2006-10-31 | 2006-11-06 | 12 | 2006-10-31 | 2006-11-06 | 3h | 0.05d | 0d | Calendario de clase (trabajo) | técnico DPE | 3h |
| 14 | 3.1.5 | pruebas del ADC y filtro | 3h | 2006-11-06 | 2006-11-08 | 13 | 2006-11-06 | 2006-11-08 | 3h | 0.05d | 0d | Calendario de clase (trabajo) | técnico DPE | 3h |
| 15 | 3.1.6 | pruebas de generación de la señal | 4h | 2006-11-08 | 2006-11-13 | 14, 25 | 2006-11-08 | 2006-11-13 | 4h | 0.05d | 0d | Calendario de clase (trabajo) | técnico DPE | 4h |
| 16 | 3.1.7 | pruebas globales | 4h | 2006-11-13 | 2006-11-15 | 23, 15 | 2006-11-13 | 2006-11-15 | 4h | 0.05d |  | Calendario de clase (trabajo) | técnico DPE | 4h |
| 17 | 3.2 | **realización del circuito impreso** | 2.8d | 2006-11-15 | 2006-11-24 | 9, 23 | 2006-11-15 | 2006-11-24 | 2.8d | 0d |  |  |  | 12h |
| 18 | 3.2.1 | diseño de la placa | 4h | 2006-11-15 | 2006-11-17 |  | 2006-11-15 | 2006-11-17 | 4h | 0.05d |  |  | técnico DPE | 4h |
| 19 | 3.2.2 | realización de la placa | 2h | 2006-11-17 | 2006-11-20 | 18 | 2006-11-17 | 2006-11-20 | 2h | 0d |  | Calendario de clase (trabajo) | técnico DPE | 2h |
| 20 | 3.2.3 | comprobación de la placa | 1h | 2006-11-20 | 2006-11-20 | 19 | 2006-11-20 | 2006-11-20 | 1h | 0d |  | Calendario de clase (trabajo) | técnico DPE | 1h |
| 21 | 3.2.4 | montaje de componentes | 1h | 2006-11-20 | 2006-11-21 | 20 | 2006-11-20 | 2006-11-21 | 1h | 0d |  | Calendario de clase (trabajo) | técnico DPE | 1h |
| 22 | 3.2.5 | pruebas de la placa | 4h | 2006-11-21 | 2006-11-24 | 21 | 2006-11-21 | 2006-11-24 | 4h | 0d |  | Calendario de clase (trabajo) | técnico DPE | 4h |
| 23 | 4 | **realización del software** | 4.59d | 2006-10-24 | 2006-11-10 | 10, 4 | 2006-10-24 | 2006-11-10 | 4.59d | 0.52d | 0.47d |  |  | 24h |
| 24 | 4.1 | diseño de alto nivel | 2h | 2006-10-24 | 2006-10-26 |  | 2006-10-24 | 2006-10-26 | 2h | 0.86d | 0d |  | técnico DPE | 2h |
| 25 | 4.2 | rutinas de generación de la señal | 8h | 2006-10-26 | 2006-10-31 | 24 | 2006-10-26 | 2006-10-31 | 8h | 0.86d | 0d |  | técnico DPE | 8h |
| 26 | 4.3 | rutinas de modificación de la frecuencia | 6h | 2006-10-31 | 2006-11-03 | 25 | 2006-10-31 | 2006-11-03 | 6h | 0.86d | 0.34d |  | técnico DPE | 6h |
| 27 | 4.4 | ensamblaje y simulación | 8h | 2006-11-03 | 2006-11-10 | 25, 26 | 2006-11-03 | 2006-11-10 | 8h | 0.27d |  | Calendario de clase (trabajo) | técnico DPE | 8h |

| ID | WBS | Task | Duration | Start | Finish | Predecessors | Baseline start | Baseline finish | Baseline duration | Total slack | Resources | Work |
| --- | --- | --- | --- | --- | --- | --- | --- | --- | --- | --- | --- | --- |
| 28 | 5 | **realización de la documentación** | 2.25d | 2006-11-24 | 2006-12-01 | 8, 23 | 2006-11-24 | 2006-12-01 | 2.25d | 0d |  | 20h |
| 29 | 5.1 | memoria descriptiva | 6h | 2006-11-24 | 2006-11-28 |  | 2006-11-24 | 2006-11-28 | 6h | 0d | técnico DPE | 6h |
| 30 | 5.2 | diseño de hardware | 4h | 2006-11-28 | 2006-11-29 | 29 | 2006-11-28 | 2006-11-29 | 4h | 0d | técnico DPE | 4h |
| 31 | 5.3 | diseño de software | 4h | 2006-11-29 | 2006-11-30 | 30 | 2006-11-29 | 2006-11-30 | 4h | 0d | técnico DPE | 4h |
| 32 | 5.4 | planos | 1h | 2006-11-29 | 2006-11-29 | 30 | 2006-11-29 | 2006-11-29 | 1h | 0.88d | técnico DPE | 1h |
| 33 | 5.5 | presupesto | 1h | 2006-11-30 | 2006-11-30 | 30, 31 | 2006-11-30 | 2006-11-30 | 1h | 0.38d | técnico DPE | 1h |
| 34 | 5.6 | manual del usuario | 2h | 2006-12-01 | 2006-12-01 | 35 | 2006-12-01 | 2006-12-01 | 2h | 0d | técnico DPE | 2h |
| 35 | 5.7 | manual del S.A.T. | 2h | 2006-11-30 | 2006-12-01 | 30, 31 | 2006-11-30 | 2006-12-01 | 2h | 0d | técnico DPE | 2h |
